# BubbleBeeJan15-2a

Schedule from MS Project, 2015-01-06 to 2015-07-24, costs in $.

## Calendars

- Standard: Mon-Fri 08:00-12:00, 13:00-17:00; Sat-Sun off. Exceptions (off unless hours are given): 2015-01-19 (MLK), 2015-02-16 (Presidents Day), 2015-05-25 (Memorial Day), 2015-07-03 to 2015-07-04 (4thJuly Rule).

## Resources

| Resource | Rate |
| --- | --- |
| Marketing | 80 |
| Research | 80 |
| Supply | 60 |
| Technical | 100 |
| Refining | 70 |
| Quality | 80 |
| Art | 60 |
| Attorney | 120 |

## Schedule

| ID | WBS | Task | Duration | Start | Finish | Predecessors | Total slack | Free slack | Resources | Work | Cost |
| --- | --- | --- | --- | --- | --- | --- | --- | --- | --- | --- | --- |
| 1 | 1 | **BeeGum Total** | 140d | 2015-01-06 | 2015-07-24 |  | 0d |  |  | 22840h | 1,798,800 |
| 2 | 1.1 | **Product Development** | 65d | 2015-01-06 | 2015-04-08 |  | 0d |  |  | 2080h | 163,200 |
| 3 | 1.1.1 | Requirement & needs survey | 15d | 2015-01-06 | 2015-01-27 |  | 0d |  | Marketing [500%] | 600h | 48,000 |
| 4 | 1.1.2 | Product specification | 20d | 2015-01-28 | 2015-02-25 | 3 | 0d |  | Marketing [200%]; Research [400%] | 960h | 76,800 |
| 5 | 1.1.3 | Shelf life report | 10d | 2015-02-26 | 2015-03-11 | 4 | 0d |  | Research [300%] | 240h | 19,200 |
| 6 | 1.1.4 | Nutrition report | 5d | 2015-02-26 | 2015-03-04 | 4 | 5d |  | Research [300%] | 120h | 9,600 |
| 7 | 1.1.5 | Secure bee materials | 20d | 2015-03-12 | 2015-04-08 | 5, 6 | 0d |  | Supply | 160h | 9,600 |
| 8 | 1.2 | **Trial** | 85d | 2015-02-26 | 2015-06-25 |  | 0d |  |  | 12720h | 994,800 |
| 9 | 1.2.1 | Assemble Equipment | 25d | 2015-02-26 | 2015-04-01 | 4 | 5d |  | Technical [1000%]; Refining [2000%] | 6000h | 480,000 |
| 10 | 1.2.2 | Trial production | 15d | 2015-04-09 | 2015-04-29 | 7, 9 | 0d |  | Supply; Technical [1000%]; Refining [1500%] | 3120h | 253,200 |
| 11 | 1.2.3 | Quality trials | 20d | 2015-04-30 | 2015-05-28 | 10 | 0d |  | Refining [500%]; Quality [300%] | 1280h | 94,400 |
| 12 | 1.2.4 | Measurement & Quality | 5d | 2015-05-29 | 2015-06-04 | 11 | 0d |  | Refining; Quality [300%] | 160h | 12,400 |
| 13 | 1.2.5 | ProductionTraining | 15d | 2015-06-05 | 2015-06-25 | 12 | 0d |  | Refining [1500%]; Quality [300%] | 2160h | 154,800 |
| 14 | 1.3 | **Logistics** | 40d | 2015-03-12 | 2015-05-06 |  | 15d |  |  | 2600h | 200,800 |
| 15 | 1.3.1 | Trial marketing | 25d | 2015-03-12 | 2015-04-15 | 5, 6 | 15d | 0d | Marketing [500%] | 1000h | 80,000 |
| 16 | 1.3.2 | Display and boxes | 15d | 2015-04-16 | 2015-05-06 | 15 | 35d |  | Marketing [200%]; Art [300%] | 600h | 40,800 |
| 17 | 1.3.3 | Distribution | 25d | 2015-03-12 | 2015-04-15 | 5, 6 | 50d |  | Marketing [500%] | 1000h | 80,000 |
| 18 | 1.4 | **Compliance** | 70d | 2015-04-16 | 2015-07-24 |  | 0d |  |  | 5440h | 440,000 |
| 19 | 1.4.1 | Health & FDA approval | 15d | 2015-04-16 | 2015-05-06 | 7, 15 | 15d |  | Attorney [300%] | 360h | 43,200 |
| 20 | 1.4.2 | Brand and product protections | 5d | 2015-04-16 | 2015-04-22 | 7, 15 | 28d |  | Attorney [300%] | 120h | 14,400 |
| 21 | 1.4.3 | Production planning etc. | 20d | 2015-06-26 | 2015-07-24 | 13, 16, 17, 19FS+20d, 20FS+17d | 0d |  | Marketing [500%]; Research; Supply [200%]; Technical [500%]; Refining [1500%]; Quality [300%] | 4960h | 382,400 |
